Schedule from MS Project, 2026-01-12 to 2026-07-01.
Microsoft

## Calendars

- Стандартный: Mon-Fri 09:00-13:00, 14:00-18:00; Sat-Sun off.

## Schedule

| ID | WBS | Task | Duration | Start | Finish | Predecessors | Total slack | Free slack | Work | ЕИ |
| --- | --- | --- | --- | --- | --- | --- | --- | --- | --- | --- |
| 1 | 1 | **"Шинопровод_ЭМ_Реконструкция М-10"** | 122.12d | 2026-01-12 | 2026-07-01 |  | 0d |  | 17539.2h |  |
| 2 | 1.1 | **Демонтажные работы** | 6d | 2026-01-12 | 2026-01-19 |  | 116.12d |  | 1287.25h |  |
| 3 | 1.1.1 | Демонтаж кабеля | 2d | 2026-01-12 | 2026-01-13 |  | 116.12d | 0d | 222.4h |  |
| 4 | 1.1.2 | Демонтаж стальных труб, проложенных на скобах диаметром: до 25 мм | 4d | 2026-01-12 | 2026-01-15 | 3SS | 116.12d | 0d | 388.5h |  |
| 5 | 1.1.3 | Монтаж связей и распорок из одиночных и парных уголков, гнутосварных профилей для пролетов: до 24 м при высоте здания до 25 м/применит.Демонтаж крепежа ТП (уголок 50*50*5) | 6d | 2026-01-12 | 2026-01-19 | 4SS | 116.12d | 0d | 622.79h |  |
| 6 | 1.1.4 | Коробка ответвительная на стене/применит.Демонтаж ответвительных коробок | 1d | 2026-01-12 | 2026-01-12 | 5SS | 121.12d |  | 53.56h | шт |
| 7 | 1.2 | **Устройство крепежных систем** | 44.75d | 2026-01-12 | 2026-03-13 |  | 0d |  | 6473.21h |  |
| 8 | 1.2.1 | **Узел А - Подвес** | 35d | 2026-01-12 | 2026-02-27 |  | 0d |  | 4124.43h |  |
| 9 | 1.2.1.1 | Конструкция металлическая для шинопроводов | 35d | 2026-01-12 | 2026-02-27 |  | 0d |  | 4124.43h |  |
| 10 | 1.2.2 | **Узел Б - Подвес двойной** | 2d | 2026-02-27 | 2026-03-02 |  | 77.38d |  | 148.77h |  |
| 11 | 1.2.2.1 | Конструкция металлическая для шинопроводов | 2d | 2026-02-27 | 2026-03-02 | 9FS-8h | 77.38d | 0d | 148.77h |  |
| 12 | 1.2.3 | **Узел В - Крепление трубы** | 18d | 2026-02-11 | 2026-03-09 |  | 77.38d |  | 2053.85h |  |
| 13 | 1.2.3.1 | Конструкция металлическая для шинопроводов | 18d | 2026-02-11 | 2026-03-09 | 11FS-106h | 77.38d | 0d | 2053.85h |  |
| 14 | 1.2.4 | **Узел Г - Подвес к потолку** | 1d | 2026-03-09 | 2026-03-10 |  | 77.38d |  | 3.21h |  |
| 15 | 1.2.4.1 | Профиль перфорированный монтажный длиной 2 м (вес 2,7кг) | 1d | 2026-03-09 | 2026-03-10 | 13 | 77.38d | 0d | 3.21h |  |
| 16 | 1.2.5 | **Узел Д - Вертикальный подъём** | 2d | 2026-03-10 | 2026-03-12 |  | 77.38d |  | 122.83h |  |
| 17 | 1.2.5.1 | Кронштейн "Переход" на: опоре/применит. | 2d | 2026-03-10 | 2026-03-12 | 15 | 77.38d | 0d | 122.83h | шт |
| 18 | 1.2.6 | **Узел Е - Огнестойкий проход** | 1d | 2026-03-12 | 2026-03-13 |  | 77.38d |  | 20.12h |  |
| 19 | 1.2.6.1 | Профиль перфорированный монтажный длиной 2 м (вес 2,7кг) | 1d | 2026-03-12 | 2026-03-13 | 17 | 77.38d | 0d | 1.99h |  |
| 20 | 1.2.6.2 | Изоляция покрытий и перекрытий изделиями из волокнистых и зернистых материалов насухо | 1d | 2026-03-12 | 2026-03-13 | 19SS | 77.38d | 0d | 0.49h | м3 |
| 21 | 1.2.6.3 | Герметизация проходов при вводе кабелей во взрывоопасные помещения уплотнительной массой | 1d | 2026-03-12 | 2026-03-13 | 20SS | 77.38d |  | 17.64h | шт |
| 22 | 1.3 | **Монтаж шинопроводов** | 97d | 2026-02-05 | 2026-06-22 |  | 0d |  | 8759.09h |  |
| 23 | 1.3.1 | Шинопровод закрытый магистральный переменного тока на ток: до 2500 А, на стойках/применит. Монтаж шинопроводов 2000А | 97d | 2026-02-05 | 2026-06-22 | 9FS-135h | 0d |  | 7643.95h |  |
| 24 | 1.3.2 | Автомат одно-, двух-, трехполюсный, устанавливаемый на конструкции: на стене или колонне, на ток до 630 А | 7d | 2026-06-11 | 2026-06-22 | 23FS-7d | 7d | 0d | 714.15h | шт |
| 25 | 1.3.3 | Рубильник на плите с центральной или боковой рукояткой или управлением штангой, устанавливаемый на металлическом основании,: трехполюсный на ток до 2500 А/применит. Монтаж рубильника с моторным приводом | 2d | 2026-06-11 | 2026-06-15 | 24SS+1h | 9.88d | 0d | 46.54h | шт |
| 26 | 1.3.4 | Прибор или аппарат/применит.Монтаж контакта доп.OA1G10 для ОТ16..125F, FT, OT200...2500E | 2d | 2026-06-11 | 2026-06-15 | 25SS | 9.88d | 0d | 20.23h | шт |
| 27 | 1.3.5 | Коробка ответвительная с предохранителем или разъединителем, или автоматом, или указателем напряжения | 4d | 2026-06-11 | 2026-06-17 | 26SS | 9.88d |  | 334.22h | шт |

| ID | WBS | Task | Duration | Start | Finish | Predecessors | Total slack | Free slack | Work | ЕИ |
| --- | --- | --- | --- | --- | --- | --- | --- | --- | --- | --- |
| 28 | 1.4 | **Установка трансформаторов** | 4d | 2026-06-22 | 2026-06-26 |  | 0d |  | 544.19h |  |
| 29 | 1.4.1 | Подстанция комплектная трансформаторная напряжением до 10 кВ с трансформатором мощностью: до 1000 кВ·А/применит.Монтаж трансформатора ТСЗД-1000/6 У(УХЛ)3; 1000кВА; 6/0,4 кВ; D/Yн-11; IP 31; НН-сверху | 4d | 2026-06-22 | 2026-06-26 | 23 | 0d |  | 408.14h | шт |
| 30 | 1.4.2 | Подстанция комплектная трансформаторная напряжением до 10 кВ с трансформатором мощностью: до 1000 кВ·А/применит.Монтаж трансформатора ТСЗД-1000/6 У(УХЛ)3; 1000кВА; 6/0,4 кВ; D/Yн-11; IP 33; НН-справа | 2d | 2026-06-22 | 2026-06-24 | 29SS | 4d | 0d | 136.05h | шт |
| 31 | 1.5 | **Подключение кабельной продукции** | 3.25d | 2026-06-19 | 2026-06-25 |  | 4d |  | 142.05h |  |
| 32 | 1.5.1 | Рукав металлический наружным диаметром: до 48 мм | 2d | 2026-06-22 | 2026-06-24 | 30SS | 4d | 0d | 116.47h |  |
| 33 | 1.5.2 | Затягивание провода в проложенные трубы и металлические рукава первого одножильного или многожильного в общей оплетке, суммарное сечение: до 16 мм2 | 1d | 2026-06-24 | 2026-06-25 | 32 | 4d |  | 9.55h |  |
| 34 | 1.5.3 | Затягивание провода в проложенные трубы и металлические рукава первого одножильного или многожильного в общей оплетке, суммарное сечение: до 2,5 мм2 | 2d | 2026-06-19 | 2026-06-23 | 32SS-2h | 5.25d |  | 16.03h |  |
| 35 | 1.6 | **Установка электрощитового оборудования (РУ-37, РУ-38, РУ-39, РУ-40, РУ-41, ШСН, ШСН-АВР, ЩТЗТ)"** | 1d | 2026-06-26 | 2026-06-29 |  | 2d |  | 125.04h |  |
| 36 | 1.6.1 | Блок управления шкафного исполнения или распределительный пункт (шкаф), устанавливаемый: на полу, высота и ширина до 1200х1000 мм | 1d | 2026-06-26 | 2026-06-29 | 29 | 2d | 0d | 27.58h | шт |
| 37 | 1.6.2 | Блок управления шкафного исполнения или распределительный пункт (шкаф), устанавливаемый: на полу, высота и ширина до 1200х1000 мм/применит.Монтаж шкаф распределительный ПР85-Эл-В-3-63А-IP54.У3 (ШСН) | 1d | 2026-06-26 | 2026-06-29 | 36SS | 2d | 0d | 11.03h | шт |
| 38 | 1.6.3 | Блок управления шкафного исполнения или распределительный пункт (шкаф), устанавливаемый: на полу, высота и ширина до 1200х1000 мм/применит.Монтаж шкаф АВР-Эл-В-63А-IP54.У3 (ШСН-АВР) | 1d | 2026-06-26 | 2026-06-29 | 37SS | 2d | 0d | 16.55h | шт |
| 39 | 1.6.4 | Блок управления шкафного исполнения или распределительный пункт (шкаф), устанавливаемый: на стене, высота и ширина до 600х600 мм/применит.Монтаж шкаф распределительный ПР85-Эл-В-3-10А-IP54.У3 (ЩТЗТ) | 1d | 2026-06-26 | 2026-06-29 | 38SS | 2d | 0d | 29.42h | шт |
| 40 | 1.6.5 | Блок управления открытого исполнения высотой и шириной до 1000х800 мм, устанавливаемый: на стене/применит.Монтаж панелей управления секционным выключателем | 1d | 2026-06-26 | 2026-06-29 | 39SS | 2d |  | 40.46h | шт |
| 41 | 1.7 | **Система заземления** | 7d | 2026-06-22 | 2026-07-01 |  | 0d |  | 208.42h |  |
| 42 | 1.7.1 | **Заземление ТП-37, ТП-38, ТП-39, КТП-40, КТП-41** | 7d | 2026-06-22 | 2026-07-01 |  | 0d |  | 208.42h |  |
| 43 | 1.7.1.1 | Проводник заземляющий открыто по строительным основаниям: из полосовой стали сечением 100 мм2 | 1d | 2026-06-22 | 2026-06-23 | 23 | 5d | 0d | 91.32h |  |
| 44 | 1.7.1.2 | Заземлитель вертикальный из угловой стали размером: 50х50х5 мм | 1d | 2026-06-23 | 2026-06-24 | 43 | 5d |  | 16.55h | шт |
| 45 | 1.7.1.3 | Проводник заземляющий из медного изолированного провода сечением 25 мм2 открыто по строительным основаниям | 2d | 2026-06-26 | 2026-06-30 | 29 | 0d |  | 91.87h |  |
| 46 | 1.7.1.4 | Монтаж мелких металлоконструкций массой до 10 кг/применит. Держатель шины заземления | 1d | 2026-06-30 | 2026-07-01 | 45 | 0d |  | 8.68h |  |
